Schedule from GanttProject, 2023-04-17 to 2023-10-16.

## Calendars

- Project calendar: Mon-Fri working; Sat-Sun off.

## Schedule

| ID | WBS | Task | Type | Duration | Start | Finish | Predecessors |
| --- | --- | --- | --- | --- | --- | --- | --- |
| 1 | 1 | Baugenehmigung | milestone | 0d | 2023-04-17 | 2023-04-17 |  |
| 2 | 2 | **ORGA** |  | 65d | 2023-04-17 | 2023-07-14 | 1 |
| 3 | 2.1 | beauftrage Absteckungen |  | 5d | 2023-04-17 | 2023-04-21 | 1 |
| 4 | 2.2 | schreibe Erdarbeiten aus |  | 10d | 2023-04-17 | 2023-04-28 | 1 |
| 5 | 2.3 | beauftrage Erdarbeiten |  | 5d | 2023-05-01 | 2023-05-05 | 4 |
| 6 | 2.4 | organisiere Baubeginnsanzeige |  | 4d | 2023-05-08 | 2023-05-11 | 5 |
| 7 | 2.5 | organisiere Bauschild |  | 1d | 2023-05-17 | 2023-05-17 | 19FF |
| 8 | 2.6 | organisiere Baustrom |  | 20d | 2023-05-16 | 2023-06-12 | 42FF |
| 9 | 2.7 | organisiere Bauwasser |  | 20d | 2023-05-11 | 2023-06-07 | 21SF, 37SF |
| 10 | 2.8 | beauftrage Hausanschluss Wasser |  | 15d | 2023-06-26 | 2023-07-14 | 48SF |
| 11 | 2.9 | beauftrage Hausanschluss Strom |  | 15d | 2023-06-26 | 2023-07-14 | 49SF |
| 12 | 2.10 | beauftrage Hausanschluss Telefon |  | 15d | 2023-06-26 | 2023-07-14 | 49SF |
| 13 | 3 | **VERMESSUNG** |  | 10d | 2023-05-18 | 2023-05-31 |  |
| 14 | 3.1 | mache Grobabsteckung |  | 1d | 2023-05-18 | 2023-05-18 | 3, 19 |
| 15 | 3.2 | mache Feinabsteckung |  | 1d | 2023-05-31 | 2023-05-31 | 21 |
| 16 | 3.3 | erstelle Schnurgerüst |  | 1d | 2023-05-31 | 2023-05-31 | 21 |
| 17 | 4 | **ERDARBEITEN** |  | 75d | 2023-05-08 | 2023-08-18 |  |
| 18 | 4.1 | rode Grundstück |  | 5d | 2023-05-08 | 2023-05-12 | 5 |
| 19 | 4.2 | entferne Mutterboden |  | 3d | 2023-05-15 | 2023-05-17 | 18 |
| 20 | 4.3 | schachte Baugrube aus |  | 5d | 2023-05-19 | 2023-05-25 | 6FS+5d, 19 |
| 21 | 4.4 | erstelle Schotterbeet |  | 3d | 2023-05-26 | 2023-05-30 | 20 |
| 22 | 4.5 | setze Lehrrohre & MSP |  | 3d | 2023-06-01 | 2023-06-05 | 15, 16 |
| 23 | 4.6 | grabe Fundamentfugen |  | 3d | 2023-06-01 | 2023-06-05 | 15, 16, 21 |
| 24 | 4.7 | baue Kranplatz |  | 2d | 2023-06-06 | 2023-06-07 | 22, 23 |
| 25 | 4.8 | demontiere Kranplatz |  | 1d | 2023-07-17 | 2023-07-17 | 47 |
| 26 | 4.9 | verlege Be- & Entwässerungsrohre |  | 5d | 2023-07-18 | 2023-07-24 | 25 |
| 27 | 4.10 | erstelle Hebeanlagenschacht |  | 1d | 2023-07-24 | 2023-07-24 | 26FF |
| 28 | 4.11 | setze Zisterne |  | 1d | 2023-07-24 | 2023-07-24 | 26FF |
| 29 | 4.12 | gestalte Einfahrt |  | 5d | 2023-08-14 | 2023-08-18 | 30 |

Notes:
- 3: Vermessungsbüro
- 6: * braucht Unterschriften und Extradokumente von Bauleiter, Architekt, Statiker & Rohbauer / * muss in Hessen 5 Tage vor Beginn komplett abgegeben sein

| ID | WBS | Task | Type | Duration | Start | Finish | Predecessors |
| --- | --- | --- | --- | --- | --- | --- | --- |
| 30 | 5 | **AUSSENANSCHLÜSSE** |  | 14d | 2023-07-25 | 2023-08-11 |  |
| 31 | 5.1 | setze Hebeanlage |  | 5d | 2023-07-25 | 2023-07-31 | 27 |
| 32 | 5.2 | verbinde Haus & Hebeanlage |  | 1d | 2023-08-01 | 2023-08-01 | 31 |
| 33 | 5.3 | verbinde Hebeanlage & Abwassernetz |  | 5d | 2023-08-01 | 2023-08-07 | 31 |
| 34 | 5.4 | verbinde Haus & Wassernetz |  | 10d | 2023-07-31 | 2023-08-11 | 48 |
| 35 | 5.5 | verbinde Haus & Stromnetz |  | 10d | 2023-07-31 | 2023-08-11 | 49 |
| 36 | 5.6 | verbinde Haus & Telefonnetz |  | 10d | 2023-07-31 | 2023-08-11 | 49 |
| 37 | 6 | **BODENPLATTE** |  | 3d | 2023-06-08 | 2023-06-12 |  |
| 38 | 6.1 | verlege Baustahlbügel |  | 2d | 2023-06-08 | 2023-06-09 | 24 |
| 39 | 6.2 | verlege Ringerder |  | 1d | 2023-06-09 | 2023-06-09 | 38FF |
| 40 | 6.3 | gieße Bodenplatte |  | 1d | 2023-06-12 | 2023-06-12 | 39 |
| 41 | 7 | **HAUSBAU** |  | 90d | 2023-06-12 | 2023-10-13 |  |
| 42 | 7.1 | baue Kran auf |  | 1d | 2023-06-12 | 2023-06-12 | 24, 40SS |
| 43 | 7.2 | stelle Haus (Rohbau) |  | 4d | 2023-06-13 | 2023-06-16 | 40, 42SS |
| 44 | 7.3 | dichte Haus ab |  | 5d | 2023-06-19 | 2023-06-23 | 43 |
| 45 | 7.4 | decke Dach |  | 10d | 2023-06-26 | 2023-07-07 | 44 |
| 46 | 7.5 | verkleide Fassade |  | 10d | 2023-06-26 | 2023-07-07 | 44 |
| 47 | 7.6 | installiere Fenster |  | 10d | 2023-07-03 | 2023-07-14 | 44FS+5d |
| 48 | 7.7 | installiere Sanitär |  | 10d | 2023-07-17 | 2023-07-28 | 46, 47 |
| 49 | 7.8 | installiere Elektrik |  | 10d | 2023-07-17 | 2023-07-28 | 46, 47 |
| 50 | 7.9 | verkleide Innenwände (Trockenbau) |  | 10d | 2023-07-31 | 2023-08-11 | 48, 49 |
| 51 | 7.10 | baue Kamin ein |  | 5d | 2023-07-17 | 2023-07-21 | 47 |
| 52 | 7.11 | gieße Estrich |  | 5d | 2023-08-14 | 2023-08-18 | 50, 51 |
| 53 | 7.12 | lasse Estrich trocknen |  | 5d | 2023-08-21 | 2023-08-25 | 52 |
| 54 | 7.13 | male Wände |  | 10d | 2023-08-28 | 2023-09-08 | 53 |
| 55 | 7.14 | setze Fliesen |  | 10d | 2023-08-28 | 2023-09-08 | 53 |
| 56 | 7.15 | integriere Heizung |  | 4d | 2023-09-11 | 2023-09-14 | 48, 55 |
| 57 | 7.16 | setze Parkett |  | 5d | 2023-09-11 | 2023-09-15 | 54, 55 |
| 58 | 7.17 | installiere Türen |  | 5d | 2023-09-18 | 2023-09-22 | 57 |
| 59 | 7.18 | komplettiere Gewerke |  | 10d | 2023-09-18 | 2023-09-29 | 57 |
| 60 | 7.19 | Abnahme | milestone | 0d | 2023-10-16 | 2023-10-16 | 59FS+10d |

Notes:
- 34: nur mit/per Wassermeister
